# andishe

Schedule from MS Project, 2017-05-31 to 2018-02-28, status date 2017-07-20, 9 hours a day.

## Calendars

- تقویم کاری شرکت: Mon-Sun 08:00-13:00, 14:00-18:00. Exceptions (off unless hours are given): 2017-05-22 to 2031-05-09 (جمعه هر ده هفته یکبار, recurring).

## Schedule

| ID | WBS | Task | Duration | Start | Finish | Predecessors | Total slack | Free slack |
| --- | --- | --- | --- | --- | --- | --- | --- | --- |
| 1 | 1 | **تجهیز کارگاه** | 30d | 2017-05-31 | 2017-07-01 |  | 0d |  |
| 2 | 1.1 | تجهیز کارگاه - تهیه شده توسط رافعی مقدم | 30d | 2017-05-31 | 2017-07-01 |  | 0d |  |
| 3 | 2 | **خاکبرداری** | 19d | 2017-06-01 | 2017-06-20 |  | 0d |  |
| 4 | 2.1 | عملیات خاکی با دست | 4d | 2017-06-17 | 2017-06-20 | 5FF+1d | 0d |  |
| 5 | 2.2 | عملیات خاکی با ماشین | 18d | 2017-06-01 | 2017-06-19 | 2SS+1d | 0d |  |
| 6 | 3 | **فونداسیون** | 17d | 2017-06-21 | 2017-07-09 |  | 0d |  |
| 7 | 3.1 | اجرای بتن مگر | 3d | 2017-06-21 | 2017-06-24 | 4 | 0d |  |
| 8 | 3.2 | آرماتوربندی فونداسیون | 9d | 2017-06-25 | 2017-07-03 | 7 | 0d |  |
| 9 | 3.3 | قالب بندی فونداسیون | 10d | 2017-06-27 | 2017-07-06 | 8SS+2d | 0d |  |
| 10 | 3.4 | بتن ریزی فونداسیون | 2d | 2017-07-08 | 2017-07-09 | 9 | 0d |  |
| 11 | 4 | **اسکلت** | 61d | 2017-07-10 | 2017-09-12 |  | 0d |  |
| 12 | 4.1 | آرماتوربندی ستون های همکف | 4d | 2017-07-10 | 2017-07-13 | 10 | 0d |  |
| 13 | 4.2 | آرماتوربندی ستون های اول | 3d | 2017-08-12 | 2017-08-14 | 22, 26 | 0d |  |
| 14 | 4.3 | قالب بندی ستون های همکف | 3d | 2017-07-14 | 2017-07-16 | 12 | 0d |  |
| 15 | 4.4 | قالب بندی ستون های اول | 3d | 2017-08-15 | 2017-08-17 | 13 | 0d |  |
| 16 | 4.5 | بتن ریزی ستون های همکف | 4d | 2017-07-17 | 2017-07-20 | 14 | 0d |  |
| 17 | 4.6 | بتن ریزی ستون های اول | 2d | 2017-08-19 | 2017-08-20 | 15 | 0d |  |
| 18 | 4.7 | آرماتوربندی تیرهای همکف | 8d | 2017-07-24 | 2017-07-31 | 20SS+2d | 189d |  |
| 19 | 4.8 | آرماتوربندی تیرهای اول | 9d | 2017-08-23 | 2017-08-31 | 21SS+2d | 160d |  |
| 20 | 4.9 | قالب بندی تیرهای همکف | 8d | 2017-07-22 | 2017-07-29 | 16 | 0d |  |
| 21 | 4.10 | قالب بندی تیرهای اول | 7d | 2017-08-21 | 2017-08-27 | 17 | 0d |  |
| 22 | 4.11 | بتن ریزی تیرهای همکف | 3d | 2017-08-09 | 2017-08-11 | 20, 26 | 0d |  |
| 23 | 4.12 | بتن ریزی تیرهای اول | 3d | 2017-09-10 | 2017-09-12 | 21, 27 | 0d |  |
| 24 | 5 | **سقف سازی** | 58d | 2017-07-10 | 2017-09-09 |  | 14d |  |
| 25 | 5.1 | ساخت تیرچه ها | 25d | 2017-07-10 | 2017-08-05 | 12SS | 151d |  |
| 26 | 5.2 | اجرای سقف همکف | 14d | 2017-07-25 | 2017-08-08 | 20SS+3d | 0d |  |
| 27 | 5.3 | اجرای سقف اول و خرپشته | 16d | 2017-08-24 | 2017-09-09 | 21SS+3d | 0d |  |
| 28 | 5.4 | کنسول ها و پله ها | 9d | 2017-08-09 | 2017-08-17 | 26 | 86d | 66d |

| ID | WBS | Task | Duration | Start | Finish | Predecessors | Total slack | Free slack |
| --- | --- | --- | --- | --- | --- | --- | --- | --- |
| 29 | 6 | **سفت کاری** | 45d | 2017-09-13 | 2017-10-31 |  | 0d |  |
| 30 | 6.1 | اجرای دیوار چینی | 27d | 2017-10-03 | 2017-10-31 | 31 | 0d |  |
| 31 | 6.2 | اجرای نبشی کشی دیوارها ،نعل درگاهی و خرپا | 18d | 2017-09-13 | 2017-10-02 | 23 | 0d |  |
| 32 | 6.3 | چهارچوب ، فریم پنجره ها،دستک و ... | 15d | 2017-10-06 | 2017-10-21 | 30SS+3d | 110d | 54d |
| 33 | 7 | **تاسیسات فاز اول** | 28d | 2017-10-15 | 2017-11-13 |  | 53d |  |
| 34 | 7.1 | اجرای لوله های فاضلاب و آب باران | 6d | 2017-10-21 | 2017-10-26 | 30FF-4d, 42FF-1d | 116d |  |
| 35 | 7.2 | اجرای لوله کشی سرد و گرم | 12d | 2017-11-01 | 2017-11-13 | 30 | 52d | 35d |
| 36 | 7.3 | اجرای کانالهای هوا و دودکش ها و هواکش | 12d | 2017-10-15 | 2017-10-26 | 30FF-4d | 68d | 0d |
| 37 | 7.4 | اجرای لوله های برق | 10d | 2017-11-01 | 2017-11-11 | 30 | 37d |  |
| 38 | 7.5 | نصب ساپورتهای تاسیساتی | 8d | 2017-10-19 | 2017-10-26 | 36FF, 42 | 68d | 51d |
| 39 | 8 | **کفسازی** | 49d | 2017-09-13 | 2017-11-04 |  | 52d |  |
| 40 | 8.1 | اجرای پوکه و شیب بندی | 12d | 2017-09-13 | 2017-09-25 | 23 | 85d | 0d |
| 41 | 8.2 | عایق کاری سرویسها | 4d | 2017-11-01 | 2017-11-04 | 30 | 14d | 0d |
| 42 | 8.3 | عایقکاری بام | 4d | 2017-09-26 | 2017-09-30 | 40 | 85d | 17d |
| 43 | 9 | **سقف کاذب** | 14d | 2017-12-06 | 2017-12-20 |  | 0d |  |
| 44 | 9.1 | اجرای سقف کاذب | 14d | 2017-12-06 | 2017-12-20 | 59, 61 | 0d |  |
| 45 | 10 | **نازک کاری** | 53d | 2017-10-23 | 2017-12-18 |  | 8d |  |
| 46 | 10.1 | گچ و خاک و سفیدکاری سقف ها و دیوارها | 16d | 2017-11-01 | 2017-11-17 | 30 | 0d |  |
| 47 | 10.2 | سیمانکاری آستر و رویه تخته ماله ای | 8d | 2017-10-23 | 2017-11-01 | 41SF, 30SS+4d | 112d |  |
| 48 | 10.3 | اجرای دیوار پوش MDF و ضربه گیر چوبی | 5d | 2017-11-06 | 2017-11-11 | 30FS+5d | 102d |  |
| 49 | 10.4 | سنگ قرنیز دیوارها | 8d | 2017-11-07 | 2017-11-15 | 46FF-2d | 0d |  |
| 50 | 10.5 | سنگ کف و پله | 12d | 2017-11-03 | 2017-11-15 | 28, 46FF-3d, 49FF | 21d | 19d |
| 51 | 10.6 | موزائیک | 19d | 2017-11-16 | 2017-12-05 | 49 | 2d | 0d |
| 52 | 10.7 | در و پنجره و نرده ها | 12d | 2017-12-06 | 2017-12-18 | 50, 61, 51 | 2d | 0d |

| ID | WBS | Task | Duration | Start | Finish | Predecessors | Total slack | Free slack |
| --- | --- | --- | --- | --- | --- | --- | --- | --- |
| 53 | 11 | **نماسازی** | 93d | 2017-11-01 | 2018-02-08 |  | 16d |  |
| 54 | 11.1 | اجرای ازاره سنگی نما | 8d | 2017-11-01 | 2017-11-08 | 30 | 16d | 0d |
| 55 | 11.2 | اجرای نمای مینرال | 5d | 2017-11-09 | 2017-11-14 | 54 | 16d | 0d |
| 56 | 11.3 | اجرای سنگ نما | 80d | 2017-11-15 | 2018-02-08 | 55 | 16d |  |
| 57 | 11.4 | اجرای نمای آجری | 80d | 2017-11-15 | 2018-02-08 | 55 | 16d |  |
| 58 | 12 | **کاشی و سرامیک** | 29d | 2017-11-05 | 2017-12-05 |  | 10d |  |
| 59 | 12.1 | کاشیکاری سرویسها | 15d | 2017-11-05 | 2017-11-20 | 41 | 14d | 0d |
| 60 | 12.2 | نصب توالتها | 4d | 2017-11-07 | 2017-11-11 | 59SS+2d, 41 | 38d | 23d |
| 61 | 12.3 | نصب سرامیک کف و دیوار | 19d | 2017-11-16 | 2017-12-05 | 49 | 0d |  |
| 62 | 13 | **تاسیسات فاز دوم** | 51d | 2017-12-06 | 2018-01-29 |  | 14d |  |
| 63 | 13.1 | نصب کولر آبی و آب سرد کن | 9d | 2017-12-21 | 2017-12-30 | 61, 43, 38, 35 | 56d |  |
| 64 | 13.2 | سیم کشی و کابل کشی | 17d | 2017-12-21 | 2018-01-08 | 37, 52, 61, 51, 46, 44 | 0d |  |
| 65 | 13.3 | نصب کلید و پریز و سایر اقلام برقی | 12d | 2018-01-09 | 2018-01-21 | 64 | 8d |  |
| 66 | 13.4 | نصب چراغها | 9d | 2018-01-09 | 2018-01-17 | 64 | 11d |  |
| 67 | 13.5 | شبکه های اطلاع رسانی و وسایل متفرقه | 8d | 2018-01-09 | 2018-01-16 | 64 | 12d |  |
| 68 | 13.6 | نصب وسایل اطفا حریق | 11d | 2018-01-09 | 2018-01-20 | 64 | 26d | 0d |
| 69 | 13.7 | نصب لوازم بهداشتی و شیرآلات | 16d | 2017-12-06 | 2017-12-23 | 59, 60, 51, 50, 61 | 15d |  |
| 70 | 13.8 | نصب تجهیزات آتش نشانی | 8d | 2018-01-21 | 2018-01-28 | 68 | 26d |  |
| 71 | 13.9 | مخازن،مبدل ها،رادیاتور و پمپ | 20d | 2018-01-09 | 2018-01-29 | 64, 35, 69, 43, 38 | 0d |  |
| 72 | 13.10 | لرزه گیر،صافی،دستگاه های کنترل و آبگرمکن | 12d | 2017-12-06 | 2017-12-18 | 73SF-1d, 61 | 67d |  |
| 73 | 13.11 | عایق و وسایل آشپزخانه | 22d | 2017-12-06 | 2017-12-29 | 61, 51 | 54d | 13d |
| 74 | 14 | **نقاشی و نصب شیشه** | 64d | 2017-12-19 | 2018-02-25 |  | 0d |  |
| 75 | 14.1 | نصب شیشه | 8d | 2017-12-19 | 2017-12-27 | 32, 52 | 56d |  |
| 76 | 14.2 | اجرای کامل نقاشی سطوح گچی | 18d | 2018-01-30 | 2018-02-18 | 66, 67, 69, 65, 71 | 0d |  |
| 77 | 14.3 | اجرای کامل نقاشی سطوح چوبی | 7d | 2018-02-19 | 2018-02-25 | 76 | 0d |  |

| ID | WBS | Task | Duration | Start | Finish | Predecessors | Total slack |
| --- | --- | --- | --- | --- | --- | --- | --- |
| 78 | 15 | **تمیزکاری و تحویل و برچیدن کارگاه** | 3d | 2018-02-26 | 2018-02-28 |  | 0d |
| 79 | 15.1 | تمیزکاری و تحویل و برچیدن کارگاه | 3d | 2018-02-26 | 2018-02-28 | 56, 75, 77, 73, 71, 70, 67, 68, 66, 65, 57 | 0d |
